Schedule from MS Project, 2009-11-16 to 2009-12-09.
Microsoft

## Calendars

- Стандартный: Mon-Fri 09:00-13:00, 14:00-18:00; Sat-Sun off.

## Schedule

| ID | WBS | Task | Duration | Start | Finish | Predecessors | Total slack | Free slack |
| --- | --- | --- | --- | --- | --- | --- | --- | --- |
| 1 | 1 | **Сборка М32-00.00.000 СБ - Магна Ins 32-L-3(1)-N** | 18d? | 2009-11-16 | 2009-12-09 |  | 0d |  |
| 2 | 1.1 | **Изготовление М32-00.10.000-425 Вал** | 1d | 2009-11-25 | 2009-11-25 |  | 0d | 2d |
| 3 | 1.1.1 | **Изготовление М32-00.10.001-425 Вал** | 2d? | 2009-11-16 | 2009-11-17 |  | 10d |  |
| 4 | 1.1.1.1 | заготовительная | 1d? | 2009-11-16 | 2009-11-16 |  | 0d |  |
| 5 | 1.1.1.2 | Токарная обработка | 1d? | 2009-11-17 | 2009-11-17 | 4 | 0d | 10d |
| 6 | 1.1.1.3 | **Изготовление М32-00.10.002 Фиксатор** | 2d? | 2009-11-16 | 2009-11-17 |  | 10d |  |
| 7 | 1.1.1.3.1 | заготовительная | 1d? | 2009-11-16 | 2009-11-16 |  | 0d |  |
| 8 | 1.1.1.3.2 | Токарная обработка | 1d? | 2009-11-17 | 2009-11-17 | 7 | 0d | 10d |
| 9 | 1.1.1.4 | Подготовительная | 1d? | 2009-11-16 | 2009-11-16 |  | 0d |  |
| 10 | 1.1.1.5 | Фрезерная обработка | 1d? | 2009-11-17 | 2009-11-17 | 9 | 0d |  |
| 11 | 1.1.1.6 | Разметка | 1d? | 2009-11-18 | 2009-11-18 | 10 | 0d |  |
| 12 | 1.1.1.7 | Сверловка | 1d? | 2009-11-19 | 2009-11-19 | 11 | 0d |  |
| 13 | 1.1.1.8 | Нарезка резьбы | 1d? | 2009-11-20 | 2009-11-20 | 12 | 0d |  |
| 14 | 1.1.1.9 | Сборка на двигатель | 1d? | 2009-11-23 | 2009-11-23 | 13 | 0d |  |
| 15 | 1.1.1.10 | Установка винта на смолу, покраска смолой | 1d? | 2009-11-24 | 2009-11-24 | 14 | 0d |  |
| 16 | 1.1.1.11 | **Изготовление М32-00.10.003 Отбойник** | 2d? | 2009-11-16 | 2009-11-17 |  | 9d | 5d |
| 17 | 1.1.1.11.1 | заготовительная | 1d? | 2009-11-16 | 2009-11-16 |  | 0d |  |
| 18 | 1.1.1.11.2 | Токарная обработка | 1d? | 2009-11-17 | 2009-11-17 | 17 | 0d | 9d |
| 19 | 1.1.1.12 | Установка отбойника | 1d? | 2009-11-25 | 2009-11-25 | 15, 16 | 0d | 4d |
| 20 | 1.2 | **Изготовление М32-00.15.000 Корпус М32** | 10d? | 2009-11-16 | 2009-11-27 |  | 2d | 0d |
| 21 | 1.2.1 | **Изготовление М32-00.22.000-425 Колонна** | 4d? | 2009-11-16 | 2009-11-19 |  | 4d | 0d |
| 22 | 1.2.1.1 | **Изготовление М32-00.22.001-425 Колонна** | 2d? | 2009-11-16 | 2009-11-17 |  | 4d | 0d |
| 23 | 1.2.1.1.1 | заготовительная | 1d? | 2009-11-16 | 2009-11-16 |  | 0d |  |
| 24 | 1.2.1.1.2 | Токарная обработка | 1d? | 2009-11-17 | 2009-11-17 | 23 | 0d | 4d |

| ID | WBS | Task | Duration | Start | Finish | Predecessors | Total slack | Free slack |
| --- | --- | --- | --- | --- | --- | --- | --- | --- |
| 25 | 1.2.1.2 | **Изготовление М32-00.22.002 Отбойник** | 2d? | 2009-11-16 | 2009-11-17 |  | 4d | 0d |
| 26 | 1.2.1.2.1 | заготовительная | 1d? | 2009-11-16 | 2009-11-16 |  | 0d |  |
| 27 | 1.2.1.2.2 | Токарная обработка | 1d? | 2009-11-17 | 2009-11-17 | 26 | 0d | 4d |
| 28 | 1.2.1.3 | слесарная: разметка, сверловка | 1d? | 2009-11-18 | 2009-11-18 | 25, 22 | 0d |  |
| 29 | 1.2.1.4 | слесарная: пайка отбойников | 1d? | 2009-11-19 | 2009-11-19 | 28 | 0d | 4d |
| 30 | 1.2.2 | **Изготовление М32-00.15.001 Фланец** | 1d? | 2009-11-16 | 2009-11-16 |  | 7d | 3d |
| 31 | 1.2.2.1 | заготовительная | 1d? | 2009-11-16 | 2009-11-16 |  | 0d | 7d |
| 32 | 1.2.2.2 | Токарная обработка | 1d? | 2009-11-16 | 2009-11-16 |  | 0d | 7d |
| 33 | 1.2.2.3 | пайка с фланцем | 1d? | 2009-11-20 | 2009-11-20 | 21 | 0d |  |
| 34 | 1.2.2.4 | Токарная обработка фланца | 1d? | 2009-11-23 | 2009-11-23 | 33 | 0d | 2d |
| 35 | 1.2.3 | **Изготовление М32-00.20.000 Корпус** | 8d? | 2009-11-16 | 2009-11-25 |  | 2d | 0d |
| 36 | 1.2.3.1 | **Изготовление М32-00.20.002 Корпус** | 3d? | 2009-11-16 | 2009-11-18 |  | 3d | 1d |
| 37 | 1.2.3.1.1 | заготовительная | 1d? | 2009-11-16 | 2009-11-16 |  | 0d |  |
| 38 | 1.2.3.1.2 | Токарная обработка | 1d? | 2009-11-17 | 2009-11-17 | 37 | 0d |  |
| 39 | 1.2.3.1.3 | Фрезерная обработка. Улитка | 1d? | 2009-11-18 | 2009-11-18 | 38 | 0d | 3d |
| 40 | 1.2.3.2 | **Изготовление М32-00.21.000 Кольцо** | 5d? | 2009-11-16 | 2009-11-20 |  | 2d | 0d |
| 41 | 1.2.3.2.1 | **Изготовление М32-00.21.001 Кольцо** | 4d? | 2009-11-16 | 2009-11-19 |  | 2d | 0d |
| 42 | 1.2.3.2.1.1 | заготовительная | 1d? | 2009-11-16 | 2009-11-16 |  | 0d |  |
| 43 | 1.2.3.2.1.2 | Токарная обработка. Проточка в размер, проточка овальности | 1d? | 2009-11-17 | 2009-11-17 | 42 | 0d |  |
| 44 | 1.2.3.2.1.3 | слесарная разметка, сверловка | 1d? | 2009-11-18 | 2009-11-18 | 43 | 0d |  |
| 45 | 1.2.3.2.1.4 | слесарная пайка штуцера | 1d? | 2009-11-19 | 2009-11-19 | 44 | 0d |  |
| 46 | 1.2.3.2.2 | Токарная обработка. Проточка под размер запрессовки корпуса М32 - 00.20.002 | 1d? | 2009-11-20 | 2009-11-20 | 45, 36, 41 | 0d | 2d |
| 47 | 1.2.3.3 | сборочная. Запрессовка корпуса М32 - 00.20.002 в кольцо | 1d? | 2009-11-23 | 2009-11-23 | 40, 36 | 0d |  |
| 48 | 1.2.3.4 | сверление и штифтовка улитки 4 шт | 1d? | 2009-11-24 | 2009-11-24 | 47 | 0d |  |
| 49 | 1.2.3.5 | Токарная обработка. Нарезка резьбы | 1d? | 2009-11-25 | 2009-11-25 | 48 | 0d | 2d |

| ID | WBS | Task | Duration | Start | Finish | Predecessors | Total slack | Free slack |
| --- | --- | --- | --- | --- | --- | --- | --- | --- |
| 50 | 1.2.4 | **Изготовление М32-00.15.002 Основание** | 1d? | 2009-11-16 | 2009-11-16 |  | 9d | 7d |
| 51 | 1.2.4.1 | Фрезерная подготовительная. | 1d? | 2009-11-16 | 2009-11-16 |  | 0d | 9d |
| 52 | 1.2.4.2 | Фрезерная обработка. | 1d? | 2009-11-16 | 2009-11-16 |  | 0d | 9d |
| 53 | 1.2.5 | пайка с корпусом и основанием | 1d? | 2009-11-26 | 2009-11-26 | 34, 35, 50 | 0d |  |
| 54 | 1.2.6 | пайка напорного патрубка | 1d? | 2009-11-27 | 2009-11-27 | 53 | 0d | 2d |
| 55 | 1.3 | установка корпуса М32-00.15.000 Корпус М32 на вал М32-00.10.000-425 с эл.двигателем | 1d? | 2009-11-30 | 2009-11-30 | 20, 2 | 0d |  |
| 56 | 1.4 | **Изготовление М11-00.00.002 Втулка скольжения** | 2d? | 2009-11-16 | 2009-11-17 |  | 11d | 9d |
| 57 | 1.4.1 | заготовительная | 1d? | 2009-11-16 | 2009-11-16 |  | 0d |  |
| 58 | 1.4.2 | Токарная обработка | 1d? | 2009-11-17 | 2009-11-17 | 57 | 0d | 11d |
| 59 | 1.5 | **Изготовление М11-00.00.003 Защитная втулка** | 2d? | 2009-11-16 | 2009-11-17 |  | 11d | 9d |
| 60 | 1.5.1 | заготовительная | 1d? | 2009-11-16 | 2009-11-16 |  | 0d |  |
| 61 | 1.5.2 | Токарная обработка | 1d? | 2009-11-17 | 2009-11-17 | 60 | 0d | 11d |
| 62 | 1.6 | установка втулок пары скольжения, с проверкой зазоров | 1d? | 2009-12-01 | 2009-12-01 | 55, 56, 59 | 0d | 2d |
| 63 | 1.7 | **Изготовление М32-00.00.003 Рабочее колесо М32** | 14d? | 2009-11-16 | 2009-12-03 |  | 0d |  |
| 64 | 1.7.1 | **Изготовление FG М32-00.00.003 Рабочее колесо М32** | 12d? | 2009-11-16 | 2009-12-01 |  | 0d |  |
| 65 | 1.7.1.1 | Подготовка оснастки и нанесение разделителя | 1d? | 2009-11-16 | 2009-11-16 |  | 0d |  |
| 66 | 1.7.1.2 | Нарезка материала | 1d? | 2009-11-17 | 2009-11-17 | 65 | 0d |  |
| 67 | 1.7.1.3 | Укладка материала в оснастку | 1d? | 2009-11-18 | 2009-11-18 | 66 | 0d |  |
| 68 | 1.7.1.4 | Приготовление связующего | 1d? | 2009-11-19 | 2009-11-19 | 67 | 0d |  |
| 69 | 1.7.1.5 | Сборка оснастки и подключение вакуумной трубки и емкости подачи связующего | 1d? | 2009-11-20 | 2009-11-20 | 68 | 0d |  |
| 70 | 1.7.1.6 | Проведение процесса RTM | 1d? | 2009-11-23 | 2009-11-23 | 69 | 0d |  |
| 71 | 1.7.1.7 | Полимеризация и оснывание связующего | 1d? | 2009-11-24 | 2009-11-24 | 70 | 0d |  |
| 72 | 1.7.1.8 | Разборка оснастки и снятие изделия | 1d? | 2009-11-25 | 2009-11-25 | 71 | 0d |  |
| 73 | 1.7.1.9 | Обрезка облоя | 1d? | 2009-11-26 | 2009-11-26 | 72 | 0d |  |
| 74 | 1.7.1.10 | Термообработка | 1d? | 2009-11-27 | 2009-11-27 | 73 | 0d |  |
| 75 | 1.7.1.11 | Механическая обработка и покраска торцов | 1d? | 2009-11-30 | 2009-11-30 | 74 | 0d |  |
| 76 | 1.7.1.12 | Сушка | 1d? | 2009-12-01 | 2009-12-01 | 75 | 0d |  |
| 77 | 1.7.2 | Фрезерная подготовительная. | 1d? | 2009-12-02 | 2009-12-02 | 76 | 0d |  |
| 78 | 1.7.3 | Фрезерная обработка. Посадка на вал | 1d? | 2009-12-03 | 2009-12-03 | 77 | 0d |  |
| 79 | 1.8 | установка раб колеса с подгонкой и проверкой зазоров | 1d? | 2009-12-04 | 2009-12-04 | 62, 63 | 0d |  |

| ID | WBS | Task | Duration | Start | Finish | Predecessors | Total slack | Free slack |
| --- | --- | --- | --- | --- | --- | --- | --- | --- |
| 80 | 1.9 | **Изготовление М40-00.00.009 Колпачок М10** | 8d? | 2009-11-16 | 2009-11-25 |  | 7d |  |
| 81 | 1.9.1 | Подготовка матрицы, нанесение разделителя | 1d? | 2009-11-16 | 2009-11-16 |  | 0d |  |
| 82 | 1.9.2 | Подготовка связующего, нарезка армирования | 1d? | 2009-11-17 | 2009-11-17 | 81 | 0d |  |
| 83 | 1.9.3 | Установка закладной, нанесение смеси в оснастку | 1d? | 2009-11-18 | 2009-11-18 | 82 | 0d |  |
| 84 | 1.9.4 | Обжатие оснастки | 1d? | 2009-11-19 | 2009-11-19 | 83 | 0d |  |
| 85 | 1.9.5 | Полимеризация | 1d? | 2009-11-20 | 2009-11-20 | 84 | 0d |  |
| 86 | 1.9.6 | Съем изделий, очистка оснастки | 1d? | 2009-11-23 | 2009-11-23 | 85 | 0d |  |
| 87 | 1.9.7 | Обрезка облоя, покраска смолой | 1d? | 2009-11-24 | 2009-11-24 | 86 | 0d |  |
| 88 | 1.9.8 | Термообработка | 1d? | 2009-11-25 | 2009-11-25 | 87 | 0d | 7d |
| 89 | 1.10 | установка защитного колпачка | 1d? | 2009-12-07 | 2009-12-07 | 79, 80 | 0d |  |
| 90 | 1.11 | **Изготовление М32-00.00.007 Заглушка** | 3d? | 2009-11-16 | 2009-11-18 |  | 13d |  |
| 91 | 1.11.1 | заготовительная | 1d? | 2009-11-16 | 2009-11-16 |  | 0d |  |
| 92 | 1.11.2 | Токарная обработка | 1d? | 2009-11-17 | 2009-11-17 | 91 | 0d |  |
| 93 | 1.11.3 | сверловка | 1d? | 2009-11-18 | 2009-11-18 | 92 | 0d | 13d |
| 94 | 1.12 | установка заглушки с проверкой зазоров | 1d? | 2009-12-08 | 2009-12-08 | 89, 90 | 0d |  |
| 95 | 1.13 | установка насоса на испытательный стенд | 1d? | 2009-12-09 | 2009-12-09 | 94 | 0d |  |
